# CSS Training Manual

Schedule from MS Project, 2011-12-19 to 2012-03-14, costs in £, A marks actual dates.
Coleman Publishing
Our goal is to be first to market with a quality product!

## Calendars

- Standard: Mon-Fri 08:00-12:00, 13:00-17:00; Sat-Sun off.

## Resources

| Resource | Group | Rate | Notes |
| --- | --- | --- | --- |
| Writer 1 |  | 45 | Software expert. |
| Editor 1 |  | 17 | Style expert. |
| Printer 1 |  | 10 | Needs setup time. |
| Artist 1 |  | 25 | Callouts, custom figures. |
| Project Manager 1 |  | 60 | Specializes in short projects. |
| Staff Assistant 1 |  | 12 | Competent under pressure. |
| Account Rep 1 |  | 20 | Very creative. |
| Publisher 1 |  | 48.08 | Lots of patience. |
| Subject Matter Expert 1 |  | 100 | From TC Agency. |
| Glossy paper | External | 150 | For final printing. |
| Plain paper |  | 75 | For printing the proof. |

## Schedule

| ID | WBS | Task | Type | Duration | Start | Finish | Predecessors | Complete | Remaining | Baseline start | Baseline finish | Baseline duration | Total slack | Resources | Work | Actual work | Cost | Baseline cost | Actual cost | Text1 |
| --- | --- | --- | --- | --- | --- | --- | --- | --- | --- | --- | --- | --- | --- | --- | --- | --- | --- | --- | --- | --- |
| 1 | 1 | Start Book | milestone | 0d | 2011-12-19 A | 2011-12-19 A |  | 100% |  | 2011-12-19 | 2011-12-19 | 0d |  | Project Manager 1; Writer 1 |  |  |  |  |  |  |
| 2 | 2 | **Research Phase** |  | 7d | 2011-12-19 A | 2011-12-27 A |  | 100% |  | 2011-12-19 | 2011-12-27 | 7d |  |  | 88h | 88h | 4,552 | 4,552 | 4,552 |  |
| 3 | 2.1 | Interview Subject Matter Expert |  | 1d | 2011-12-19 A | 2011-12-19 A |  | 100% |  | 2011-12-19 | 2011-12-19 | 1d |  | Project Manager 1; Writer 1; Subject Matter Expert 1 | 24h | 24h | 1,640 | 1,640 | 1,640 |  |
| 4 | 2.2 | Investigate the software |  | 4d | 2011-12-20 A | 2011-12-23 A | 3 | 100% |  | 2011-12-20 | 2011-12-23 | 4d |  | Writer 1 | 32h | 32h | 2,000 | 2,000 | 2,000 |  |
| 5 | 2.3 | Search the Web |  | 2d | 2011-12-26 A | 2011-12-27 A | 4 | 100% |  | 2011-12-26 | 2011-12-27 | 2d |  | Writer 1; Staff Assistant 1 | 32h | 32h | 912 | 912 | 912 |  |
| 6 | 3 | **Outline Phase** |  | 10d | 2011-12-28 A | 2012-01-10 A |  | 100% |  | 2011-12-28 | 2012-01-10 | 10d |  |  | 110h | 110h | 6,094.61 | 6,094.61 | 6,094.62 |  |
| 7 | 3.1 | Create outline |  | 3d | 2011-12-28 A | 2011-12-30 A | 5 | 100% |  | 2011-12-28 | 2011-12-30 | 3d |  | Writer 1 | 24h | 24h | 1,200 | 1,200 | 1,200 | CSS Outline.doc |
| 8 | 3.2 | Present to publisher |  | 1d | 2012-01-02 A | 2012-01-02 A | 7 | 100% |  | 2012-01-02 | 2012-01-02 | 1d |  | Writer 1; Project Manager 1; Publisher 1 | 24h | 24h | 1,224.61 | 1,224.61 | 1,224.62 |  |
| 9 | 3.3 | Review with Subject Matter Expert |  | 2.25d | 2012-01-03 A | 2012-01-05 A | 8 | 100% |  | 2012-01-03 | 2012-01-05 | 2.25d |  | Writer 1; Subject Matter Expert 1 | 32h | 32h | 2,320 | 2,320 | 2,320 |  |
| 10 | 3.4 | Revise outline |  | 3.75d | 2012-01-05 A | 2012-01-10 A | 9 | 100% |  | 2012-01-05 | 2012-01-10 | 3.75d |  | Writer 1 | 30h | 30h | 1,350 | 1,350 | 1,350 |  |
| 11 | 4 | **Development Phase** |  | 38d | 2012-01-11 A | 2012-03-02 |  | 41% | 22.52d | 2012-01-11 | 2012-02-16 | 27d | 0d |  | 256h | 88h | 9,400 | 9,400 | 3,960 |  |
| 12 | 4.1 | Write content |  | 22d | 2012-01-11 A | 2012-02-09 | 10 | 50% | 11d | 2012-01-11 | 2012-02-09 | 22d | 0d | Writer 1 | 176h | 88h | 7,920 | 7,920 | 3,960 |  |
| 13 | 4.2 | Add graphics |  | 5d | 2012-02-10 | 2012-03-02 | 12 |  |  | 2012-02-10 | 2012-02-16 | 5d | 0d | Artist 1; Staff Assistant 1 | 80h |  | 1,480 | 1,480 |  |  |
| 14 | 5 | **Edit Phase** |  | 4d | 2012-03-02 | 2012-03-07 |  |  |  | 2012-02-16 | 2012-02-21 | 4d | 0d |  | 56h |  | 3,608 | 3,608 |  |  |
| 15 | 5.1 | Check grammar, spelling, and proofread |  | 3d | 2012-03-05 | 2012-03-07 | 13 |  |  | 2012-02-17 | 2012-02-21 | 3d | 0d | Editor 1 | 24h |  | 408 | 408 |  |  |
| 16 | 5.2 | Check for technical accuracy |  | 4d | 2012-03-02 | 2012-03-07 | 15FF |  |  | 2012-02-16 | 2012-02-21 | 4d | 0d | Subject Matter Expert 1 | 32h |  | 3,200 | 3,200 |  |  |
| 17 | 6 | **Review Phase** |  | 2d | 2012-03-08 | 2012-03-09 |  |  |  | 2012-02-22 | 2012-02-23 | 2d | 0d |  | 24h |  | 856 | 856 |  |  |
| 18 | 6.1 | Approve editing changes |  | 1d | 2012-03-08 | 2012-03-08 | 16 |  |  | 2012-02-22 | 2012-02-22 | 1d | 0d | Writer 1 | 8h |  | 360 | 360 |  |  |
| 19 | 6.2 | Meet with editor |  | 1d | 2012-03-09 | 2012-03-09 | 18 |  |  | 2012-02-23 | 2012-02-23 | 1d | 0d | Writer 1; Editor 1 | 16h |  | 496 | 496 |  |  |
| 20 | 7 | **Print Phase** |  | 3d | 2012-03-12 | 2012-03-14 |  |  |  | 2012-02-24 | 2012-02-28 | 3d | 0d |  | 42h |  | 1,361 | 1,361 |  |  |
| 21 | 7.1 | Print proof |  | 1d | 2012-03-12 | 2012-03-12 | 19 |  |  | 2012-02-24 | 2012-02-24 | 1d | 0d | Printer 1; Plain paper | 9h |  | 155 | 155 |  |  |
| 22 | 7.2 | Review proof |  | 1d | 2012-03-13 | 2012-03-13 | 21 |  |  | 2012-02-27 | 2012-02-27 | 1d | 0d | Writer 1; Editor 1; Project Manager 1 | 24h |  | 976 | 976 |  |  |
| 23 | 7.3 | Print final |  | 1d | 2012-03-14 | 2012-03-14 | 22 |  |  | 2012-02-28 | 2012-02-28 | 1d | 0d | Printer 1; Glossy paper | 9h |  | 230 | 230 |  |  |
| 24 | 8 | Book Complete | milestone | 0d | 2012-03-14 | 2012-03-14 | 23 |  |  | 2012-02-28 | 2012-02-28 | 0d | 0d | Project Manager 1; Writer 1 |  |  |  |  |  |  |

Notes:
- 7: Send the outline to Marketing.
- 13: Post the CSS course file to the Content Management System.
- 21: Provide a hard copy proof to Project Manager.
- 24: Deliver final course.
